Schedule from MS Project, 2003-04-21 to 2003-09-22.
tea

## Calendars

- Standard: Mon-Fri 08:00-12:00, 13:00-17:00; Sat-Sun off. Exceptions (off unless hours are given): 2003-04-26 08:00-12:00, 13:00-17:00.

## Resources

| Resource |
| --- |
| no |
| A1 |
| A2 |
| B1 |
| A3 |
| C1 |
| C2 |
| D1 |
| D2 |
| B2 |
| D4.1 |
| D4.2.D3.E3 |
| E1 |
| E2 |
| C3 |
| F1 |
| D4.3 |
| E3 |
| F2 |
| F3 |
| G1 |
| G2 |

## Schedule

| ID | Task | Duration | Start | Finish | Predecessors | Total slack | Free slack | Constraint | Resources | Work |
| --- | --- | --- | --- | --- | --- | --- | --- | --- | --- | --- |
| 1 | A1.确定信息流 | 5d | 2003-04-21 | 2003-04-25 |  | 85d | 0d | start no earlier than 2003-04-20 | no | 40h |
| 2 | A2.确定软件要求 | 3d | 2003-04-26 | 2003-04-29 | 1 | 85d | 0d |  | A1 | 24h |
| 3 | A3.确定硬件要求 | 2d | 2003-04-30 | 2003-05-01 | 2 | 85d | 0d |  | A2 | 16h |
| 4 | B1.系统流程图准备 | 5d | 2003-04-30 | 2003-05-06 |  | 99d |  | start no earlier than 2003-04-30 | A2 | 40h |
| 5 | B2.数据库程序修改 | 10d | 2003-05-07 | 2003-05-20 |  | 69d | 0d | start no earlier than 2003-05-07 | B1 | 80h |
| 6 | C1.硬件与供应商选择 | 1d | 2003-05-02 | 2003-05-02 | 3 | 85d | 0d |  | A3 | 8h |
| 7 | C2.采购订单处理 | 1d | 2003-05-05 | 2003-05-05 | 6 | 85d | 0d |  | C1 | 8h |
| 8 | C3.硬件接收 | 15d | 2003-05-06 | 2003-05-26 | 7 | 85d |  |  | C2 | 120h |
| 9 | D1.人力资源需求确定 | 2d | 2003-05-02 | 2003-05-05 |  | 0d |  | start no earlier than 2003-05-02 | A3 | 16h |
| 10 | D2.公司内人员调任 | 15d | 2003-05-06 | 2003-05-26 | 9 | 0d |  |  | D1 | 120h |
| 11 | D3.外部人员招聘 | 20d | 2003-05-27 | 2003-06-23 | 10 | 0d |  |  | D2 | 160h |
| 12 | D4.1.用户手册准备 | 10d | 2003-05-21 | 2003-06-03 | 5 | 69d | 0d |  | B2; C1 | 160h |
| 13 | D4.2.培训内容确定 | 10d | 2003-06-04 | 2003-06-17 | 12 | 69d |  |  | D4.1 | 80h |
| 14 | D4.3.培训 | 4d | 2003-06-24 | 2003-06-27 | 11 | 0d |  |  | D4.2.D3.E3 | 32h |
| 15 | E1.设施布置 | 3d | 2003-05-06 | 2003-05-08 |  | 97d |  | start no earlier than 2003-05-06 | C1; D1 | 48h |
| 16 | E2.设施修改 | 15d | 2003-05-09 | 2003-05-29 |  | 77d | 0d | start no earlier than 2003-05-09 | E1 | 120h |
| 17 | E3.设备安装 | 5d | 2003-05-30 | 2003-06-05 | 16 | 77d |  |  | E2; C3 | 80h |
| 18 | F1.小规模测试评估方法确定 | 2d | 2003-06-30 | 2003-07-01 |  | 59d |  | start no earlier than 2003-06-30 | A1 | 16h |
| 19 | F2.小规模测试 | 30d | 2003-06-30 | 2003-08-08 | 14 | 0d |  |  | F1; D4.3; E3 | 720h |
| 20 | F3.测试评估 | 5d | 2003-08-11 | 2003-08-15 | 19 | 0d |  |  | F2 | 40h |
| 21 | G1.系统修改（根据需要） | 10d | 2003-08-18 | 2003-08-29 | 20 | 0d |  |  | F3 | 80h |
| 22 | G2.执行方案审定 | 1d | 2003-09-01 | 2003-09-01 | 21 | 0d |  |  | G1 | 8h |
| 23 | G3.全面办公自动化执行 | 15d | 2003-09-02 | 2003-09-22 | 22 | 0d |  |  | G2 | 120h |
